# Example Project Schedule Ver5-Print

Schedule from MS Project, 2016-02-11 to 2017-12-05.
Division of Aviation

## Calendars

- Standard: Mon-Fri 08:00-12:00, 13:00-17:00; Sat-Sun off.

## Schedule

| ID | WBS | Task | Type | Duration | Start | Finish | Predecessors | Total slack | Free slack |
| --- | --- | --- | --- | --- | --- | --- | --- | --- | --- |
| 1 | 1 | Award Letter Sent to Airport | milestone | 0d | 2016-02-11 | 2016-02-11 |  | 0d |  |
| 2 | 2 | **Request for Aid (RFA) Process** |  | 77d | 2016-02-11 | 2016-05-27 |  | 0d |  |
| 3 | 2.1 | Request for Aid sent to airport |  | 1d | 2016-02-11 | 2016-02-11 |  | 56d |  |
| 4 | 2.2 | Schedule and Hold Scoping Meeting |  | 2w | 2016-02-11 | 2016-02-24 | 1 | 0d |  |
| 5 | 2.3 | Scoping Meeting | milestone | 0d | 2016-02-24 | 2016-02-24 | 4 | 0d |  |
| 6 | 2.4 | Develop Work Authorization Scope and Project Schedule |  | 15d | 2016-02-25 | 2016-03-16 | 5 | 0d |  |
| 7 | 2.5 | Negotiate Work Authorization and Fee w/ Consultant and send to DoA |  | 5d | 2016-03-17 | 2016-03-23 | 6 | 0d |  |
| 8 | 2.6 | Sponsor gains Local Certification of Funds from Governing Board |  | 4w | 2016-03-24 | 2016-04-20 | 7 | 7d |  |
| 9 | 2.7 | APM reviews and comments on Schedule and Work Authorization |  | 12d | 2016-03-24 | 2016-04-08 | 7 | 0d |  |
| 10 | 2.8 | Sponsor and Consultant Respond to Comments |  | 5d | 2016-04-11 | 2016-04-15 | 9 | 0d |  |
| 11 | 2.9 | Sponsor Execution of Work Authorization |  | 2w | 2016-04-18 | 2016-04-29 | 10 | 0d |  |
| 12 | 2.10 | Sponsor attaches required documentation to Project Request |  | 3d | 2016-05-02 | 2016-05-04 | 1, 11, 3, 8 | 0d |  |
| 13 | 2.11 | APM reviews and Approves Request for Aid |  | 12d | 2016-05-05 | 2016-05-20 | 12 | 0d |  |
| 14 | 2.12 | Grant Admin Reviews and Approves request |  | 1w | 2016-05-23 | 2016-05-27 | 13 | 0d |  |
| 15 | 3 | **Grant Agreement Process** |  | 42d | 2016-05-30 | 2016-07-26 |  | 0d |  |
| 16 | 3.1 | Paper Grant Created and Sponsor Notified |  | 1w | 2016-05-30 | 2016-06-03 | 14 | 0d |  |
| 17 | 3.2 | Grant Agreement mailed to Airport Sponsor |  | 5d | 2016-06-06 | 2016-06-10 | 16 | 0d |  |
| 18 | 3.3 | Sponsor has agreement signed by Governing Board |  | 3w | 2016-06-13 | 2016-07-01 | 17 | 0d |  |
| 19 | 3.4 | Sponsor Mails agreement back to DoA |  | 5d | 2016-07-04 | 2016-07-08 | 18 | 0d |  |
| 20 | 3.5 | GA sends agreement to Deputy Secretary of Transit |  | 2w | 2016-07-11 | 2016-07-22 | 19 | 0d |  |
| 21 | 3.6 | Agreement signed by Deputy Secretary of Transit | milestone | 0d | 2016-07-22 | 2016-07-22 | 20 | 0d |  |
| 22 | 3.7 | GA issues Design Notice to Proceed and sends to Airport Sponsor |  | 2d | 2016-07-25 | 2016-07-26 | 21 | 0d |  |
| 23 | 4 | **Design** |  | 74d | 2016-07-27 | 2016-11-07 |  | 0d |  |
| 24 | 4.1 | **Preliminary Design Tasks** |  | 5d | 2016-07-27 | 2016-08-02 |  | 0d |  |
| 25 | 4.1.1 | Surveying |  | 2d | 2016-07-27 | 2016-07-28 | 22 | 3d |  |
| 26 | 4.1.2 | Geotechnical Investigations |  | 3d | 2016-07-27 | 2016-07-29 | 22 | 2d |  |
| 27 | 4.1.3 | Schedule and Hold Initial Design Meeting |  | 5d | 2016-07-27 | 2016-08-02 | 22, 26FF, 25FF | 0d |  |
| 28 | 4.1.4 | Initial Design Meeting | milestone | 0d | 2016-08-02 | 2016-08-02 | 27 | 0d |  |
| 29 | 4.2 | 30% Design |  | 3w | 2016-08-03 | 2016-08-23 | 28 | 3d | 0d |
| 30 | 4.3 | 30% Design Meeting | milestone | 0d | 2016-08-23 | 2016-08-23 | 29 | 4d | 0d |
| 31 | 4.4 | Submit Design to APM for Comments |  | 1d | 2016-08-24 | 2016-08-24 | 29 | 3d | 0d |
| 32 | 4.5 | Cost Estimate developed off of Design |  | 3d | 2016-08-24 | 2016-08-26 | 30 | 30d | 0d |

| ID | WBS | Task | Type | Duration | Start | Finish | Predecessors | Total slack | Free slack |
| --- | --- | --- | --- | --- | --- | --- | --- | --- | --- |
| 33 | 4.6 | **DBE/MBE/WBE Goal Determination** |  | 14d | 2016-08-29 | 2016-09-15 |  | 30d |  |
| 34 | 4.6.1 | Send Cost Estimate to DoA for DBE/MBE/WBE Goal |  | 2d | 2016-08-29 | 2016-08-30 | 32 | 30d | 0d |
| 35 | 4.6.2 | APM sends estimate to Contractual Services Unit |  | 1d | 2016-08-31 | 2016-08-31 | 34 | 30d | 0d |
| 36 | 4.6.3 | CSU returns goal determination to APM |  | 10d | 2016-09-01 | 2016-09-14 | 35 | 30d | 0d |
| 37 | 4.6.4 | APM sends goal determination to Sponsor |  | 1d | 2016-09-15 | 2016-09-15 | 36 | 30d | 24d |
| 38 | 4.7 | **Environmental Documentation** |  | 29d | 2016-08-03 | 2016-09-12 |  | 0d |  |
| 39 | 4.7.1 | Determine level of Environmental Document Required |  | 2d | 2016-08-03 | 2016-08-04 | 28 | 0d |  |
| 40 | 4.7.2 | Environmental Documentation developed and submited to DoA |  | 15d | 2016-08-05 | 2016-08-25 | 39 | 0d |  |
| 41 | 4.7.3 | DoA Reviews and Responds to Environmental Documentation |  | 12d | 2016-08-26 | 2016-09-12 | 40 | 0d |  |
| 42 | 4.8 | 60% Design |  | 2w | 2016-08-25 | 2016-09-07 | 30, 31 | 3d | 0d |
| 43 | 4.9 | Submit Design to APM for Comments w/ CSPP | milestone | 0d | 2016-09-07 | 2016-09-07 | 42 | 76d | 0d |
| 44 | 4.10 | APM sends comments For CSPP back to Sponsor |  | 3d | 2016-09-08 | 2016-09-12 | 43 | 76d | 0d |
| 45 | 4.11 | Sponsor/Consultant sends 7460 and CSPP w/ APM Comments to FAA using OE/AAA |  | 40d | 2016-09-13 | 2016-11-07 | 44 | 76d |  |
| 46 | 4.12 | 90% Design |  | 2w | 2016-09-13 | 2016-09-26 | 42, 41 | 0d |  |
| 47 | 4.13 | 90% Design Meeting | milestone | 0d | 2016-09-26 | 2016-09-26 | 46 | 0d |  |
| 48 | 4.14 | Submit Design to APM for Comments | milestone | 0d | 2016-09-26 | 2016-09-26 | 46 | 311d |  |
| 49 | 4.15 | Final Design |  | 1w | 2016-09-27 | 2016-10-03 | 47 | 0d |  |
| 50 | 4.16 | Review of Design by APM |  | 12d | 2016-10-04 | 2016-10-19 | 49 | 6d | 0d |
| 51 | 5 | **Bid Process** |  | 60d | 2016-10-04 | 2016-12-26 |  | 0d |  |
| 52 | 5.1 | Develop Work Authorization for CA/RPR and negotiate with Consultant; Submit to DoA with Updated Schedule |  | 2w | 2016-10-04 | 2016-10-17 | 49 | 0d |  |
| 53 | 5.2 | APM reviews and comments on Updated Schedule and Work Authorization |  | 12d | 2016-10-18 | 2016-11-02 | 52 | 0d |  |
| 54 | 5.3 | Sponsor and Consultant Respond to Comments |  | 3d | 2016-11-03 | 2016-11-07 | 53 | 0d |  |
| 55 | 5.4 | Sponsor Execution of Work Authorization |  | 3w | 2016-11-08 | 2016-11-28 | 54 | 0d |  |
| 56 | 5.5 | Advertise project |  | 2d | 2016-10-20 | 2016-10-21 | 50, 37, 52 | 6d | 0d |
| 57 | 5.6 | Hold Pre-Bid Meeting |  | 5d | 2016-10-24 | 2016-10-28 | 56 | 6d | 0d |
| 58 | 5.7 | Bid Period |  | 2w | 2016-10-31 | 2016-11-11 | 57, 52 | 6d | 0d |
| 59 | 5.8 | Publish Meeting Minutes and Respond to RFIs |  | 2w | 2016-10-31 | 2016-11-11 | 58FF, 57 | 6d | 0d |
| 60 | 5.9 | Review bids/proposals |  | 5d | 2016-11-14 | 2016-11-18 | 59, 58 | 6d |  |
| 61 | 5.10 | Determine bid winner | milestone | 0d | 2016-11-28 | 2016-11-28 | 60, 55 | 0d |  |
| 62 | 5.11 | Sponsor gains approval from Governing Board to award construction contract and requests Certification of Local Funds for Construction |  | 4w | 2016-11-29 | 2016-12-26 | 61 | 0d |  |

| ID | WBS | Task | Type | Duration | Start | Finish | Predecessors | Total slack | Constraint |
| --- | --- | --- | --- | --- | --- | --- | --- | --- | --- |
| 63 | 6 | **Construction Grant Modification and Approval Process** |  | 41d | 2016-12-27 | 2017-02-21 |  | 0d |  |
| 64 | 6.1 | Sponsor requests Grant Modification for Construction |  | 1d | 2016-12-27 | 2016-12-27 | 62, 54 | 0d |  |
| 65 | 6.2 | Construction Request for Aid sent to Sponsor |  | 3d | 2016-12-28 | 2016-12-30 | 64 | 0d |  |
| 66 | 6.3 | Request for Aid documentation uploaded to Partner Connect |  | 5d | 2017-01-02 | 2017-01-06 | 65 | 0d |  |
| 67 | 6.4 | APM reviews package and forwards to GA |  | 12d | 2017-01-09 | 2017-01-24 | 66 | 0d |  |
| 68 | 6.5 | GA reviews package |  | 3d | 2017-01-25 | 2017-01-27 | 67 | 0d |  |
| 69 | 6.6 | GA sends package to Deputy Secretary of Transit |  | 2w | 2017-01-30 | 2017-02-10 | 68 | 0d |  |
| 70 | 6.7 | Grant Modification Approved by Deputy Secretary of Transit | milestone | 0d | 2017-02-10 | 2017-02-10 | 69 | 0d |  |
| 71 | 6.8 | GA sends Notice to Proceed for Construction |  | 2d | 2017-02-13 | 2017-02-14 | 70 | 0d |  |
| 72 | 6.9 | Sponsor executes work agreement with contractor |  | 1w | 2017-02-15 | 2017-02-21 | 71, 62 | 0d |  |
| 73 | 7 | **Construction** |  | 180d | 2017-02-22 | 2017-10-31 |  | 0d |  |
| 74 | 7.1 | Schedule and Hold Pre-Construction Meeting/Send out Minutes |  | 1w | 2017-02-22 | 2017-02-28 | 45, 72 | 0d |  |
| 75 | 7.2 | Contractor Mobilization |  | 2w | 2017-03-01 | 2017-03-14 | 74 | 0d |  |
| 76 | 7.3 | Site Preparations |  | 1w | 2017-03-15 | 2017-03-21 | 75 | 0d |  |
| 77 | 7.4 | Construction Process w/ regular progress meetings |  | 150d | 2017-03-22 | 2017-10-17 | 76 | 0d |  |
| 78 | 7.5 | Pre-final and Final Inspection Process |  | 10d | 2017-10-18 | 2017-10-31 | 77 | 0d |  |
| 79 | 8 | **Project Closeout** |  | 25d | 2017-11-01 | 2017-12-05 |  | 0d |  |
| 80 | 8.1 | As-Builts to DoA |  | 2w | 2017-11-01 | 2017-11-14 | 78 | 0d |  |
| 81 | 8.2 | Final Resolution of Invoices |  | 2w | 2017-11-15 | 2017-11-28 | 80 | 5d |  |
| 82 | 8.3 | Submit Final Project Documents to DoA including DBE Statements Etc |  | 15d | 2017-11-15 | 2017-12-05 | 80 | 0d |  |
| 83 | 9 | Warranty Period | manual | 0.05mo | 2016-02-11 | 2016-02-11 |  |  | start no earlier than 2017-05-30 |
